# Margin&CanyonEngineeringSchedule

Schedule from MS Project, 2014-05-02 to 2015-10-16, A marks actual dates.
Hewlett-Packard Company

## Calendars

- Standard: Mon-Fri 08:00-12:00, 13:00-17:00; Sat-Sun off.

## Resources

| Resource |
| --- |
| Mark Chaffey |
| Tom O'Reilly |
| E Tech |
| Johnny Ferreira |

## Schedule

| ID | WBS | Task | Type | Duration | Start | Finish | Predecessors | Complete | Remaining | Baseline start | Baseline finish | Baseline duration | Total slack | Free slack | Constraint | Resources | Work | Actual work |
| --- | --- | --- | --- | --- | --- | --- | --- | --- | --- | --- | --- | --- | --- | --- | --- | --- | --- | --- |
| 1 | 1 | Western Flyer on GOC Expedition |  | 71d? | 2015-02-06 A | 2015-05-16 |  | 13% | 62d? | 2015-02-06 | 2015-05-16 | 71d? | 110d |  | finish no earlier than 2015-05-16 |  |  |  |
| 2 | 2 | Roberto & Charlie GOC |  | 9d? | 2015-05-05 | 2015-05-16 |  |  |  |  |  |  | 110d |  | finish no earlier than 2015-05-16 |  |  |  |
| 3 | 3 | O'Reilly Vacation |  | 16d? | 2015-05-11 | 2015-06-01 |  |  |  |  |  |  | 99d |  | start no earlier than 2015-05-11 |  |  |  |
| 4 | 4 | Roberto out |  | 14d? | 2015-06-11 | 2015-06-30 |  |  |  |  |  |  | 78d |  | finish no earlier than 2015-06-30 |  |  |  |
| 5 | 5 | Installation of BINs and instruments in building G |  | 8.33d? | 2014-05-02 A | 2014-05-13 A |  | 100% |  | 2014-05-02 | 2014-05-14 | 8.33d? |  |  | start no earlier than 2014-05-02 | Mark Chaffey [60%] | 40h | 40h |
| 6 | 6 | Receipt of ADCP's from NERC | milestone | 0d | 2015-03-16 | 2015-03-16 |  |  |  | 2015-03-16 | 2015-03-16 | 0d | 154d |  | finish no earlier than 2015-03-16 |  |  |  |
| 7 | 7 | Preliminary power budget testing |  | 1.67d? | 2014-05-15 A | 2014-05-16 A | 5 | 100% |  | 2014-05-15 | 2014-05-16 | 1.67d? |  |  | start no earlier than 2014-05-13 | Tom O'Reilly [60%]; Mark Chaffey [60%] | 16h | 16h |
| 8 | 8 | Preliminary system design |  | 8.33d? | 2014-05-19 A | 2014-05-29 A |  | 100% |  | 2014-05-19 | 2014-05-29 | 8.33d? |  |  | start no earlier than 2014-05-18 | Mark Chaffey [60%] | 40h | 40h |
| 9 | 9 | Functional Requirements Review | milestone | 0d | 2014-06-02 A | 2014-06-02 A | 7, 8 | 100% |  | 2014-06-02 | 2014-06-02 | 0d |  |  | must start on 2014-06-02 | Mark Chaffey [60%]; Tom O'Reilly [60%] |  |  |
| 10 | 10 | Purchase of acoustic modem |  | 3.33d | 2015-01-16 A | 2015-01-21 A | 9 | 100% |  | 2015-01-16 | 2015-01-21 | 3.33d |  |  | start no earlier than 2014-05-05 | Mark Chaffey [60%] | 16h | 16h |
| 11 | 11 | **BIN Software Development and Testing** |  | 138d? | 2014-10-13 A | 2015-04-23 |  | 75% | 34.64d? | 2014-10-13 | 2015-04-23 | 138d? | 126.33d |  |  |  | 809.6h | 609.2h |
| 12 | 11.1 | Software integration of Acoustic Modem |  | 8.33d? | 2015-01-14 A | 2015-02-25 | 5 | 50% | 4.17d? | 2015-01-14 | 2015-01-26 | 8.33d? | 159.83d | 40.5d | start no earlier than 2015-01-14 | Tom O'Reilly [60%] | 40h | 20h |
| 13 | 11.2 | Software integration of 600 and 1200kHz ADCP's |  | 16.67d | 2015-03-17 A | 2015-04-08 A | 6, 18FF | 100% |  | 2015-03-17 | 2015-04-08 | 16.67d |  |  |  | Tom O'Reilly [60%]; Mark Chaffey [60%] | 88h | 88h |
| 14 | 11.3 | Software integration and testing of instrument interfaces |  | 137d | 2014-10-13 A | 2015-04-22 | 5, 12FF, 13FF, 38FF | 75% | 34.25d | 2014-10-13 | 2015-04-22 | 137d | 119.33d | 0d | start no earlier than 2014-07-28 | Tom O'Reilly [60%]; Mark Chaffey [60%] | 665.6h | 501.2h |
| 15 | 11.4 | Software verification of data format and load path to SSDS |  | 3.33d? | 2015-04-17 | 2015-04-22 | 14FF |  |  | 2015-04-17 | 2015-04-22 | 3.33d? | 127.33d |  |  | Tom O'Reilly [60%] | 16h |  |
| 16 | 11.5 | Preliminary instrument readiness review |  | 1d | 2015-04-22 A | 2015-04-23 A | 14 | 100% |  | 2015-04-22 | 2015-04-23 | 1d |  |  |  |  |  |  |
| 17 | 12 | **BIN Electrical Design** |  | 170d | 2015-01-14 A | 2015-09-08 |  | 25% | 127.74d | 2015-01-14 | 2015-05-15 | 88d | 28d |  |  |  | 1022h | 494h |
| 18 | 12.1 | Overall system design including instrument interfaces, batteries, cabling, and fault protection |  | 34.5d | 2015-01-14 A | 2015-04-03 A | 9 | 100% |  | 2015-01-14 | 2015-01-27 | 10d |  |  | start no earlier than 2015-01-14 | Mark Chaffey; Tom O'Reilly [50%] | 414h | 414h |
| 19 | 12.2 | Integration and testing of improved RTC |  | 8.33d | 2015-04-06 | 2015-04-16 | 18 |  |  | 2015-01-28 | 2015-02-09 | 8.33d | 84d | 0d |  | Mark Chaffey [60%] | 40h |  |
| 20 | 12.3 | Preliminary electrical design review | milestone | 0d | 2015-04-16 | 2015-04-16 | 19, 18 |  |  | 2015-02-09 | 2015-02-09 | 0d | 84d | 0d |  | Mark Chaffey [60%] |  |  |
| 21 | 12.4 | Detailed electrical design of instrument interface for Acoustic Modem including cables |  | 3.33d | 2015-04-16 | 2015-04-21 | 20 |  |  | 2015-02-09 | 2015-02-12 | 3.33d | 87.33d | 0d | start no earlier than 2014-07-12 | Mark Chaffey [60%] | 16h |  |
| 22 | 12.5 | Fabrication of cables for Acoustic Modem |  | 20d | 2015-04-21 | 2015-05-19 | 21 |  |  | 2015-02-12 | 2015-03-12 | 20d | 87.33d | 13.33d |  |  |  |  |
| 23 | 12.6 | Detailed design of instrument interfaces for 600 and 1200kHz ADCP's including cables |  | 6.67d | 2015-04-16 | 2015-04-24 | 20 |  |  | 2015-02-09 | 2015-02-17 | 6.67d | 84d | 0d | start no earlier than 2015-01-14 | Mark Chaffey [60%] | 32h |  |
| 24 | 12.7 | Fabrication of cables for NERC ADCP's |  | 20d | 2015-04-27 | 2015-05-22 | 23 |  |  | 2015-02-18 | 2015-03-17 | 20d | 84d | 10d | start no earlier than 2014-05-11 |  |  |  |
| 25 | 12.8 | Detailed electrical design of battery system including cables |  | 16.67d | 2015-04-16 A | 2015-05-08 A | 46FF, 20 | 100% |  | 2015-02-24 | 2015-03-18 | 16.67d |  |  | start no earlier than 2015-02-24 | Mark Chaffey [60%] | 80h | 80h |
| 26 | 12.9 | Fabrication of battery to BIN cables |  | 35d | 2015-07-22 A | 2015-09-08 | 25 |  | 35d | 2015-03-18 | 2015-04-29 | 30d | 12d | 0d |  |  |  |  |
| 27 | 12.10 | Layout and fabrication of battery interface board |  | 20d | 2015-05-11 | 2015-06-05 | 25 |  |  | 2015-03-18 | 2015-04-15 | 20d | 74d | 0d | start no earlier than 2014-09-19 | E Tech; Mark Chaffey [60%] | 168h |  |

| ID | WBS | Task | Type | Duration | Start | Finish | Predecessors | Complete | Remaining | Baseline start | Baseline finish | Baseline duration | Total slack | Free slack | Constraint | Resources | Work | Actual work |
| --- | --- | --- | --- | --- | --- | --- | --- | --- | --- | --- | --- | --- | --- | --- | --- | --- | --- | --- |
| 28 | 12.11 | **Battery Spheres** |  | 128d | 2015-02-17 | 2015-08-13 |  |  |  | 2015-02-17 | 2015-05-15 | 64d | 30d |  |  |  | 208h |  |
| 29 | 12.11.1 | Delivery of battery sphere cables | milestone | 0d | 2015-03-25 | 2015-03-25 |  |  |  | 2015-03-25 | 2015-03-25 | 0d | 112d | 0d | start no earlier than 2015-03-25 |  |  |  |
| 30 | 12.11.2 | Delivery of Benthos battery spheres #1 - 16 | milestone | 0d | 2015-04-07 | 2015-04-07 | 29FS+10d |  |  | 2015-04-07 | 2015-04-07 | 0d | 112d | 0d | start no earlier than 2015-03-25 |  |  |  |
| 31 | 12.11.3 | Delivery of battery packs for sphere #1-4 | milestone | 0d | 2015-02-17 | 2015-02-17 |  |  |  | 2015-02-17 | 2015-02-17 | 0d | 148d | 43d | start no earlier than 2015-02-17 |  |  |  |
| 32 | 12.11.4 | Delivery of battery packs for sphere's #5-#8 | milestone | 0d | 2015-04-17 | 2015-04-17 |  |  |  | 2015-04-17 | 2015-04-17 | 0d | 105d | 0d | start no earlier than 2015-04-17 |  |  |  |
| 33 | 12.11.5 | Delivery of battery packs for sphere's #9-#16 | milestone | 0d | 2015-07-31 | 2015-07-31 |  |  |  | 2015-04-17 | 2015-04-17 | 0d | 30d | 0d | start no earlier than 2015-07-31 |  |  |  |
| 34 | 12.11.6 | Documentation on battery safety, handling and assembly procedures |  | 5d | 2015-03-25 | 2015-03-31 |  |  |  | 2015-03-25 | 2015-03-31 | 5d | 124d | 5d | start no earlier than 2015-03-25 | Mark Chaffey [60%] | 24h |  |
| 35 | 12.11.7 | Assembly of battery sphere #1 |  | 3d | 2015-04-08 | 2015-04-10 | 34, 30 |  |  | 2015-04-08 | 2015-04-10 | 3d | 119d | 107d |  | E Tech | 24h |  |
| 36 | 12.11.8 | Assembly of battery spheres #2-#8 |  | 10d | 2015-04-17 | 2015-04-30 | 32, 30, 31 |  |  | 2015-04-17 | 2015-04-30 | 10d | 105d | 93d |  | E Tech | 80h |  |
| 37 | 12.11.9 | Assembly of battery spheres #9-#16 |  | 10d | 2015-07-31 | 2015-08-13 | 33, 30 |  |  | 2015-05-04 | 2015-05-15 | 10d | 30d | 18d | start no earlier than 2015-05-03 | E Tech | 80h |  |
| 38 | 12.12 | Final assembly of BIN #1 and instruments |  | 5d | 2015-06-08 | 2015-06-12 | 24, 27, 22 |  |  | 2015-04-15 | 2015-04-22 | 5d | 82d | 0d |  | Mark Chaffey [60%] | 24h |  |
| 39 | 12.13 | BIN power energy budget verification testing |  | 3.33d | 2015-06-15 | 2015-06-19 | 38 |  |  | 2015-04-22 | 2015-04-29 | 3.33d | 85d |  | start no earlier than 2015-01-14 | Mark Chaffey [60%]; Tom O'Reilly [60%] | 16h |  |
| 40 | 12.14 | Final assembly of BIN #2 and instruments |  | 5d | 2015-06-08 | 2015-06-12 | 24, 27, 22 |  |  | 2015-04-17 | 2015-04-23 | 5d | 74d | 62d | start no earlier than 2015-04-17 | Mark Chaffey [60%] | 24h |  |
| 41 | 13 | **BIN Assembly Mechanical Design** |  | 59d | 2015-01-21 A | 2015-04-13 |  | 5% | 56.14d | 2015-01-21 | 2015-04-13 | 59d | 118d |  |  |  | 868.8h | 40h |
| 42 | 13.1 | Preliminary design of steel frame modifications and instrument mount |  | 5d | 2015-01-21 A | 2015-01-27 A | 18FF | 100% |  | 2015-01-21 | 2015-01-27 | 5d |  |  | start no earlier than 2015-01-14 | Johnny Ferreira | 40h | 40h |
| 43 | 13.2 | Deployed hardware weight estimate |  | 1d | 2015-02-18 | 2015-02-18 | 42 |  |  | 2015-01-28 | 2015-01-28 | 1d | 124d | 0d | start no earlier than 2015-02-18 | Johnny Ferreira; Mark Chaffey [60%] | 12.8h |  |
| 44 | 13.3 | Verify Western Flyer winch deployment and recovery weight limits |  | 1d | 2015-02-19 | 2015-02-19 | 43 |  |  | 2015-01-29 | 2015-01-29 | 1d | 124d | 0d |  | Mark Chaffey [60%] | 4.8h |  |
| 45 | 13.4 | Deployment and recovery lifting sling design |  | 2d | 2015-02-20 | 2015-02-23 | 44 |  |  | 2015-01-30 | 2015-02-02 | 2d | 124d | 0d |  | Johnny Ferreira | 16h |  |
| 46 | 13.5 | Preliminary Mechanical Design Review | milestone | 0d | 2015-02-23 | 2015-02-23 | 42, 44, 45 |  |  | 2015-02-02 | 2015-02-02 | 0d | 124d | 0d | start no earlier than 2014-01-01 | Johnny Ferreira; Mark Chaffey [60%] |  |  |
| 47 | 13.6 | Final Design of steel frame modifications and mount |  | 5d | 2015-02-24 | 2015-03-02 | 46 |  |  | 2015-02-03 | 2015-02-09 | 5d | 128d | 4d |  | Johnny Ferreira | 40h |  |
| 48 | 13.7 | Detailed mechanical design of battery system frame |  | 9d | 2015-02-24 | 2015-03-06 | 46 |  |  | 2015-02-16 | 2015-02-26 | 9d | 124d | 0d | start no earlier than 2015-02-14 | Mark Chaffey [60%]; Johnny Ferreira | 115.2h |  |
| 49 | 13.8 | Fabrication of modifications to steel frame #1 and instrument mounts |  | 20d | 2015-03-09 | 2015-04-03 | 48, 47 |  |  | 2015-02-27 | 2015-03-26 | 20d | 124d | 112d |  | Johnny Ferreira | 160h |  |
| 50 | 13.9 | Fabrication of battery system frame components #1 |  | 20d | 2015-03-16 | 2015-04-10 | 48 |  |  | 2015-03-16 | 2015-04-10 | 20d | 119d | 107d | start no earlier than 2015-03-16 | Johnny Ferreira | 160h |  |
| 51 | 13.10 | Fabrication of modifications to steel frame #2 and instrument mounts |  | 20d | 2015-03-09 | 2015-04-03 | 47, 48 |  |  | 2015-02-27 | 2015-03-26 | 20d | 124d | 112d |  | Johnny Ferreira | 160h |  |
| 52 | 13.11 | Fabrication of battery system frame components #2 |  | 20d | 2015-03-17 | 2015-04-13 | 48 |  |  | 2015-03-17 | 2015-04-13 | 20d | 118d | 106d | start no earlier than 2015-03-17 | Johnny Ferreira | 160h |  |

Notes:
- 30: Battery cables must be delivered first.

| ID | WBS | Task | Type | Duration | Start | Finish | Predecessors | Baseline start | Baseline finish | Baseline duration | Total slack | Free slack | Constraint | Resources | Work |
| --- | --- | --- | --- | --- | --- | --- | --- | --- | --- | --- | --- | --- | --- | --- | --- |
| 53 | 14 | **Final System Integration and Test** |  | 10d | 2015-09-09 | 2015-09-22 |  | 2015-05-01 | 2015-05-29 | 21d | 12d |  |  |  | 195.2h |
| 54 | 14.1 | Final assemby of all deployed hardware for BIN assembly #1 |  | 5d | 2015-09-09 | 2015-09-15 | 35, 36, 49, 50, 26 | 2015-05-01 | 2015-05-07 | 5d | 12d | 0d |  | Johnny Ferreira; Mark Chaffey [60%] | 64h |
| 55 | 14.2 | Final assemby of all deployed hardware for BIN assembly #2 |  | 5d | 2015-09-09 | 2015-09-15 | 37, 40, 51, 52, 26 | 2015-05-18 | 2015-05-22 | 5d | 12d | 0d |  | Johnny Ferreira; Mark Chaffey [60%] | 64h |
| 56 | 14.3 | Final instrument readiness review |  | 2d | 2015-09-16 | 2015-09-17 | 14, 55 | 2015-05-25 | 2015-05-26 | 2d | 15d | 3d |  | Tom O'Reilly [60%]; Mark Chaffey [60%] | 19.2h |
| 57 | 14.4 | Cold soak testing unit 1 |  | 3d | 2015-09-16 | 2015-09-18 | 54 | 2015-05-25 | 2015-05-27 | 3d | 12d | 0d |  | Mark Chaffey [60%] | 14.4h |
| 58 | 14.5 | Test tank testing unit 1 |  | 2d | 2015-09-21 | 2015-09-22 | 57 | 2015-05-28 | 2015-05-29 | 2d | 12d | 0d |  | Mark Chaffey [60%] | 9.6h |
| 59 | 14.6 | Cold soak testing unit 2 |  | 3d | 2015-09-16 | 2015-09-18 | 55 | 2015-05-25 | 2015-05-27 | 3d | 12d | 0d |  | Mark Chaffey [60%] | 14.4h |
| 60 | 14.7 | Test tank testing unit 2 |  | 2d | 2015-09-21 | 2015-09-22 | 59 | 2015-05-28 | 2015-05-29 | 2d | 12d | 0d |  | Mark Chaffey [60%] | 9.6h |
| 61 | 15 | BINs ready for deployment | milestone | 0d | 2015-09-22 | 2015-09-22 | 56, 58, 60 | 2015-05-29 | 2015-05-29 | 0d | 12d |  |  |  |  |
| 62 | 16 | Stage for deployment |  | 1d | 2015-10-09 | 2015-10-09 | 61 | 2015-10-09 | 2015-10-09 | 1d | 0d |  | as late as possible |  |  |
| 63 | 17 | Load Western Flyer |  | 1d | 2015-10-12 | 2015-10-12 | 62 | 2015-10-12 | 2015-10-12 | 1d | 0d |  |  |  |  |
| 64 | 18 | Deployment cruise |  | 4d | 2015-10-13 | 2015-10-16 | 63 | 2015-10-13 | 2015-10-16 | 4d | 0d |  | must start on 2015-10-13 |  |  |
